# Proyecto de Ejemplo 1

Schedule from MS Project, 2024-10-01 to 2026-02-13, 6 hours a day.

## Calendars

- Calendario L-Mi-V: Mon 08:00-12:00, 13:00-15:00; Tue off; Wed 08:00-12:00, 13:00-15:00; Thu off; Fri 08:00-12:00, 13:00-15:00; Sat-Sun off. Exceptions (off unless hours are given): 2025-01-01 (Año Nuevo), 2025-01-06 (Dia de Reyes), 2025-01-21 (Virgen De La Altagracia), 2025-02-27 (Independencia Nacional), 2025-04-17 (Jueves Santos), 2025-04-18 (Viernes santos), 2025-05-01 (Dia Del Trabajador), 2025-06-19 (Corpus Christi), 2025-09-24 (Dia de La Mercedes), 2025-11-10 (Dia de La Constitucion), 2025-12-24 (Noche Buena), 2025-12-25 (Navidad), 2025-12-31 (Fin de Año), 2026-01-01 (Año Nuevo), 2026-01-06 (Dia de Reyes), 2026-01-21 (Dia de La Altagracia), 2026-01-26 (Juan Pablo Duarte).
- Calendario Ma y J: Mon off; Tue 08:00-12:00, 13:00-15:00; Wed off; Thu 08:00-12:00, 13:00-15:00; Fri-Sun off. Exceptions (off unless hours are given): 2025-01-01 (Año Nuevo), 2025-01-06 (Dia de Reyes), 2025-01-21 (Virgen De La Altagracia), 2025-02-27 (Independencia Nacional), 2025-04-17 (Jueves Santos), 2025-04-18 (Viernes Santos), 2025-05-01 (Dia Del Trabajador), 2025-06-19 (Corpus Christi), 2025-08-16 (Dia de la Restauracion), 2025-09-24 (Dia de Las Mercedes), 2025-11-10 (Dia de la Constitucion), 2025-12-24 (Noche Buena), 2025-12-25 (Navidad), 2025-12-31 (Fin de Año), 2026-01-01 (Año Nuevo), 2026-01-06 (Dia de Reyes), 2026-01-21 (Dia de La Altagracia), 2026-01-26 (Dia de Duarte).
- Estándar con día feriados: Mon-Fri 09:00-13:00, 15:00-19:00; Sat-Sun off. Exceptions (off unless hours are given): 2025-01-01 (Año Nuevo), 2025-01-06 (Dia de Reyes), 2025-01-21 (Virgen de la Altagracia), 2025-02-27 (Independencia Nacional), 2025-04-17 (Jueves Santos), 2025-04-18 (Viernes Santos), 2025-05-01 (Dia del Trabajador), 2025-06-19 (Corpus Christi), 2025-09-24 (Dia de Las Mercedes), 2025-11-10 (Dia de la Constitucion), 2025-12-24 (Noche Buena), 2025-12-25 (Navidad), 2025-12-31 (Fin de Año), 2026-01-01 (Año Nuevo), 2026-01-06 (Dis de Reyes), 2026-01-21 (Virgen de La Altagracia), 2026-01-26 to 2026-01-27 (Dia de Juan Pablo Duarte).

## Resources

| Resource |
| --- |
| Hoyero 1 |
| Hoyero 2 |
| Hoyero 3 |
| Hoyero 4 |
| Hoyero 5 |
| Hoyero 6 |
| Hoyero 7 |
| Hoyero 8 |
| Hoyero 9 |
| Hoyero 10 |
| Grúa 1 |
| Grúa 2 |
| Grúa 3 |
| Grúa 4 |
| Grúa 5 |
| Canasto 1 |
| Canasto 2 |
| Canasto 3 |
| Canasto 4 |
| Canasto 5 |
| Canasto 6 |
| Canasto 7 |
| Canasto 8 |
| Canasto 9 |
| Canasto 10 |
| Brigada de Normalización 1 |
| Brigada de Normalización 2 |
| Brigada de Normalización 3 |
| Brigada de Normalización 4 |
| Brigada de Normalización 5 |
| Supervisor 1 |
| Supervisor 2 |
| Supervisor 3 |
| Supervisor 4 |
| Supervisor 5 |
| Supervisor 6 |
| Supervisor 7 |
| Supervisor 8 |
| Supervisor 9 |
| Supervisor 10 |
| Capataz 1 |
| Capataz 2 |
| Capataz 3 |
| Capataz 4 |
| Capataz 5 |
| Capataz 6 |
| Capataz 7 |
| Capataz 8 |
| Capataz 9 |
| Capataz 10 |
| Brigada de Poda 1 |
| Brigada de Poda 2 |
| Brigada de Poda 3 |
| Brigada de Poda 4 |
| Brigada de Poda 5 |
| Brigada de Poda 6 |
| Brigada de Poda 7 |
| Brigada de Poda 8 |
| Brigada de Poda 9 |
| Brigada de Poda 10 |
| Brigada Ligera 1 |
| Brigada Ligera 2 |
| Brigada Ligera 3 |
| Brigada Ligera 4 |
| Brigada Ligera 5 |
| Brigada Ligera 6 |
| Brigada Ligera 7 |
| Brigada Ligera 8 |
| Brigada Ligera 9 |
| Brigada Ligera 10 |
| Hoyero 1 A |
| Hoyero 2 B |
| Hoyero 3 C |
| Hoyero 4 D |
| Hoyero 5 E |
| Hoyero 6 F |
| Hoyero 7 G |
| Hoyero 8 H |
| Hoyero 9 I |
| Hoyero 10 J |
| Grúa 1 A |
| Grúa 2 B |
| Grúa 3 C |
| Grúa 4 D |
| Grúa 5 E |
| Canasto 1 A |
| Canasto 2 B |
| Canasto 3 C |
| Canasto 4 D |
| Canasto 5 E |
| Canasto 6 F |
| Canasto 7 G |
| Canasto 8 H |
| Canasto 9 I |
| Canasto 10 J |
| Brigada de Normalización 1 A |
| Brigada de Normalización 2 B |
| Brigada de Normalización 3 C |
| Brigada de Normalización 4 D |
| Brigada de Normalización 5 E |
| Brigada de Normalización 6 F |
| Brigada de Normalización 7 G |
| Brigada de Normalización 8 H |
| Brigada de Normalización 9 I |
| Brigada de Normalización 10 J |
| Supervisor 1 A |
| Supervisor 2 B |
| Supervisor 3 C |
| Supervisor 4 D |
| Supervisor 5 E |
| Supervisor 6 F |
| Supervisor 7 G |
| Supervisor 8 H |
| Supervisor 9 I |
| Supervisor 10 J |
| Capataz 1 A |
| Capataz 2 B |
| Capataz 3 C |
| Capataz 4 D |
| Capataz 5 E |
| Capataz 6 F |
| Capataz 7 G |
| Capataz 8 H |
| Capataz 9 I |
| Capataz 10 J |
| Brigada de Poda 1 A |
| Brigada de Poda 2 B |
| Brigada de Poda 3 C |
| Brigada de Poda 4 D |
| Brigada de Poda 5 E |
| Brigada de Poda 6 F |
| Brigada de Poda 7 G |
| Brigada de Poda 8 H |
| Brigada de Poda 9 I |
| Brigada de Poda 10 J |
| Brigada Ligera 1 A |
| Brigada Ligera 2 B |
| Brigada Ligera 3 C |
| Brigada Ligera 4 D |
| Brigada Ligera 5 E |
| Brigada Ligera 6 F |
| Brigada Ligera 7 G |
| Brigada Ligera 8 H |
| Brigada Ligera 9 I |
| Brigada Ligera 10 J |
| Hoyero 11 |
| Hoyero 12 |
| Hoyero 13 |
| Hoyero 14 |
| Hoyero 15 |
| Hoyero 11 K |
| Hoyero 12 L |
| Hoyero 13 M |
| Hoyero 14 N |
| Hoyero 15 Ñ |

## Schedule

| ID | WBS | Task | Duration | Start | Finish | Predecessors | Total slack | Free slack | Constraint | Calendar | Resources | Work | Días Calendario | Cantidad |
| --- | --- | --- | --- | --- | --- | --- | --- | --- | --- | --- | --- | --- | --- | --- |
| 1 | 1 | **Proyecto Lote-04 COTU104 CEVICOS** | 454d | 2024-10-01 | 2026-02-13 |  | 0d |  |  | Estándar con día feriados |  | 12606h | 501días |  |
| 2 | 1.1 | **Preparativos previos Obras** | 44d | 2024-10-01 | 2024-11-14 |  | 0d |  |  | Estándar con día feriados |  |  | 45días |  |
| 3 | 1.1.1 | Reuniones con Contratista | 5d | 2024-10-01 | 2024-10-04 |  | 0d |  | start no earlier than 2024-10-01 | Estándar con día feriados |  |  | 4días |  |
| 4 | 1.1.2 | Revisiones adicionales de Ingenieria-Replanteo | 30d | 2024-10-07 | 2024-11-06 | 3FS+1d | 0d |  |  | Estándar con día feriados |  |  | 31días |  |
| 5 | 1.1.3 | Firma Minuta | 7d | 2024-11-07 | 2024-11-14 | 4FS+1d | 0d |  |  | Estándar con día feriados |  |  | 8días |  |
| 6 | 1.1.4 | Obtension Recursos Contratista | 30d | 2024-10-07 | 2024-11-06 |  | 418.67d |  | start no earlier than 2024-10-07 | Estándar con día feriados |  |  | 31días |  |
| 7 | 1.1.5 | Gestion de Materiales y Revision contra Fichas Tecnicas | 21d | 2024-10-07 | 2024-10-29 | 3FS+1d | 427d |  |  | Estándar con día feriados |  |  | 23días |  |
| 8 | 1.2 | **Suministro Materiales** | 119d | 2024-10-17 | 2025-02-24 |  | 319d |  |  | Estándar con día feriados |  |  | 131días |  |
| 9 | 1.2.1 | Suministro Postes | 90d | 2024-10-17 | 2025-01-23 | 4SS+10d | 319d | 0d |  | Estándar con día feriados |  |  | 99días |  |
| 10 | 1.2.2 | Suministro Armados | 90d | 2024-10-31 | 2025-02-06 | 9SS+14d | 319d | 0d |  | Estándar con día feriados |  |  | 99días |  |
| 11 | 1.2.3 | Suministro Tendido (Cables) | 90d | 2024-11-15 | 2025-02-24 | 10SS+15d | 319d | 0d |  | Estándar con día feriados |  |  | 102días |  |
| 12 | 1.2.4 | Suministro Transformadores | 90d | 2024-11-15 | 2025-02-24 | 11SS | 319d |  |  | Estándar con día feriados |  |  | 102días |  |
| 13 | 1.2.5 | Suministro Equipos Proteccion | 90d | 2024-11-15 | 2025-02-24 | 11SS | 319d |  |  | Estándar con día feriados |  |  | 102días |  |
| 14 | 1.2.6 | Suminiostro Alumbrado Publico | 90d | 2024-11-15 | 2025-02-24 | 11SS | 319d |  |  | Estándar con día feriados |  |  | 102días |  |
| 15 | 1.2.7 | Suministro Acometida y medidores | 90d | 2024-11-15 | 2025-02-24 | 11SS | 319d |  |  | Estándar con día feriados |  |  | 102días |  |
| 16 | 1.3 | **Ejecucion de Obras** | 186d | 2024-11-18 | 2026-02-13 |  | 0d |  |  |  |  | 12606h | 453días |  |
| 17 | 1.3.1 | **Poligono 1** | 43d | 2024-11-18 | 2025-02-28 |  | 0d |  |  |  |  | 1272h | 103días |  |
| 18 | 1.3.1.1 | Excavaciones | 3d | 2024-11-18 | 2024-11-22 | 5FS+1d | 0d |  |  |  | Hoyero 3; Hoyero 4; Hoyero 5; Hoyero 6; Hoyero 7; Hoyero 8; Hoyero 9; Hoyero 10; Hoyero 1; Hoyero 2; Hoyero 11; Hoyero 12; Hoyero 13; Hoyero 14; Hoyero 15 | 270h | 5días | 187 |
| 19 | 1.3.1.2 | Izado de postes | 3d | 2024-11-18 | 2024-11-22 | 18SS | 143d | 0d |  |  | Grúa 3; Grúa 1; Grúa 2; Grúa 4; Grúa 5 | 90h | 5días | 89 |
| 20 | 1.3.1.3 | Cimentaciones | 1d | 2025-01-03 | 2025-01-03 | 19FF | 166d |  |  |  | Brigada Ligera 1 | 6h | 1días |  |
| 21 | 1.3.1.4 | Retenidas | 2d | 2024-11-22 | 2024-11-25 | 19SS+2d | 143d | 0d |  |  | Brigada Ligera 3; Brigada Ligera 2; Canasto 1; Brigada Ligera 4; Brigada Ligera 5 | 60h | 4días | 98 |
| 22 | 1.3.1.5 | Armados MT y BT | 4d | 2024-11-27 | 2024-12-04 | 21 | 143d | 0d |  |  | Canasto 3; Canasto 4; Canasto 5; Canasto 2; Canasto 1 | 120h | 8días | 152 |
| 23 | 1.3.1.6 | Tendido de Conductor MT y BT | 2d | 2024-12-06 | 2024-12-09 | 22 | 143d | 0d |  |  | Canasto 3; Canasto 2; Canasto 1; Canasto 4; Canasto 5 | 60h | 4días | 3,691 |
| 24 | 1.3.1.7 | Puesta a Tierra | 2d | 2024-12-11 | 2024-12-13 | 23 | 143d | 0d |  |  | Canasto 5; Canasto 4; Canasto 1; Canasto 2; Canasto 3 | 60h | 3días | 122 |
| 25 | 1.3.1.8 | Conexiones y Jumper | 6d | 2024-12-16 | 2024-12-27 | 24 | 143d | 0d |  |  | Canasto 1; Canasto 2; Canasto 3; Canasto 4; Canasto 5 | 180h | 12días | 317 |
| 26 | 1.3.1.9 | Transformadores | 1d | 2024-12-30 | 2024-12-30 | 25 | 143d | 0d |  |  | Grúa 1; Canasto 1 | 12h | 1días |  |
| 27 | 1.3.1.10 | Alumbrado Público | 5d | 2025-01-03 | 2025-01-15 | 26 | 143d | 0d |  |  | Canasto 2; Canasto 1; Canasto 3; Canasto 4; Canasto 5 | 150h | 13días | 90 |
| 28 | 1.3.1.11 | Etiquetas CT | 1d | 2025-01-17 | 2025-01-17 | 27 | 143d | 0d |  |  | Canasto 1; Canasto 2 | 12h | 1días | 35 |
| 29 | 1.3.1.12 | Totalizadores | 4d | 2025-01-20 | 2025-01-27 | 28 | 157d |  |  |  | Canasto 3; Canasto 4; Canasto 5 | 72h | 8días | 35 |
| 30 | 1.3.1.13 | Acometida | 11d | 2025-01-27 | 2025-02-19 | 28FS+3d | 143d | 0d |  |  | Brigada de Normalización 1; Brigada de Normalización 2 | 132h | 24días | 457 |
| 31 | 1.3.1.14 | Remoción | 4d | 2025-02-21 | 2025-02-28 | 30SS+11d | 143d |  |  |  | Canasto 1; Grúa 1 | 48h | 8días | 204 |

Notes:
- 19: No se le asigna canasto, pero requiere uno para apertura y cierre de seccionador
- 23: Con una grua es suficiente para darle apoyo a los canastos.

| ID | WBS | Task | Duration | Start | Finish | Predecessors | Total slack | Free slack | Calendar | Resources | Work | Días Calendario | Cantidad |
| --- | --- | --- | --- | --- | --- | --- | --- | --- | --- | --- | --- | --- | --- |
| 33 | 1.3.2 | **Poligono 2** | 105d | 2024-11-21 | 2025-12-09 |  | 16d |  | Calendario Ma y J |  | 3714h | 384días |  |
| 34 | 1.3.2.1 | Excavaciones | 12d | 2024-11-21 | 2024-12-31 | 5FS+1d | 16d | 0d | Calendario Ma y J | Hoyero 3 C; Hoyero 4 D; Hoyero 5 E; Hoyero 6 F; Hoyero 7 G; Hoyero 8 H; Hoyero 9 I; Hoyero 10 J; Hoyero 1 A; Hoyero 2 B; Hoyero 11 K; Hoyero 12 L; Hoyero 13 M; Hoyero 14 N; Hoyero 15 Ñ | 1080h | 41días | 695 |
| 35 | 1.3.2.2 | Izado de postes | 13d | 2024-11-21 | 2025-01-02 | 34SS | 16d | 0d | Calendario Ma y J | Grúa 3 C; Grúa 1 A; Grúa 2 B; Grúa 4 D | 312h | 43días | 361 |
| 36 | 1.3.2.3 | Cimentaciones | 1d | 2025-01-02 | 2025-01-02 | 35FF | 108d |  | Calendario Ma y J | Brigada Ligera 1 A | 6h | 1días |  |
| 37 | 1.3.2.4 | Retenidas | 8d | 2024-12-12 | 2025-01-07 | 35SS+6d | 16d | 0d | Calendario Ma y J | Brigada Ligera 2 B; Brigada Ligera 3 C; Canasto 1 A; Brigada Ligera 4 D; Brigada Ligera 5 E | 240h | 27días | 334 |
| 38 | 1.3.2.5 | Armados MT y BT | 14d | 2025-01-09 | 2025-03-04 | 37 | 16d | 0d | Calendario Ma y J | Canasto 3 C; Canasto 4 D; Canasto 5 E; Canasto 2 B; Canasto 1 A | 420h | 55días | 551 |
| 39 | 1.3.2.6 | Tendido de Conductor MT y BT | 11d | 2025-03-06 | 2025-04-10 | 38 | 16d | 0d | Calendario Ma y J | Canasto 3 C; Canasto 4 D; Canasto 5 E; Canasto 1 A; Canasto 2 B | 330h | 36días | 19,324 |
| 40 | 1.3.2.7 | Puesta a Tierra | 5d | 2025-04-15 | 2025-05-06 | 39 | 16d | 0d | Calendario Ma y J | Canasto 2 B; Canasto 3 C; Canasto 1 A; Canasto 4 D; Canasto 5 E | 150h | 22días | 244 |
| 41 | 1.3.2.8 | Conexiones y Jumper | 5d | 2025-05-08 | 2025-05-22 | 40 | 16d | 0d | Calendario Ma y J | Canasto 5 E; Canasto 4 D; Canasto 1 A; Canasto 2 B; Canasto 3 C | 150h | 15días | 238 |
| 42 | 1.3.2.9 | Transformadores | 2d | 2025-05-27 | 2025-05-29 | 41 | 16d | 0d | Calendario Ma y J | Grúa 2 B; Grúa 3 C; Canasto 1 A; Canasto 2 B; Canasto 3 C; Grúa 1 A; Grúa 4 D; Grúa 5 E; Canasto 4 D; Canasto 5 E | 120h | 3días | 27 |
| 43 | 1.3.2.10 | Alumbrado Público | 5d | 2025-06-03 | 2025-06-17 | 42 | 16d | 0d | Calendario Ma y J | Canasto 5 E; Canasto 4 D; Canasto 1 A; Canasto 2 B; Canasto 3 C | 150h | 15días | 345 |
| 44 | 1.3.2.11 | Etiquetas CT | 1d | 2025-06-24 | 2025-06-24 | 43 | 16d | 0d | Calendario Ma y J | Canasto 2 B; Canasto 1 A; Canasto 3 C | 18h | 1días | 48 |
| 45 | 1.3.2.12 | Totalizadores | 3d | 2025-06-26 | 2025-07-03 | 44 | 16d | 0d | Calendario Ma y J | Canasto 1 A; Canasto 3 C; Canasto 2 B; Canasto 4 D; Canasto 5 E | 90h | 8días | 48 |
| 46 | 1.3.2.13 | Acometida | 36d | 2025-07-01 | 2025-10-30 | 45SS+1d | 16d | 0d | Calendario Ma y J | Brigada de Normalización 1 A; Brigada de Normalización 2 B | 432h | 122días | 1,453 |
| 47 | 1.3.2.14 | Remoción | 9d | 2025-11-11 | 2025-12-09 | 46FS+2d | 16d |  | Calendario Ma y J | Canasto 1 A; Canasto 2 B; Grúa 2 B; Grúa 1 A | 216h | 29días | 903 |
| 49 | 1.3.3 | **Poligono 3** | 182d | 2024-11-27 | 2026-02-13 |  | 0d |  |  |  | 7620h | 444días |  |
| 50 | 1.3.3.1 | Excavaciones | 24d | 2024-11-27 | 2025-01-24 | 18FS+1d | 0d |  |  | Hoyero 5; Hoyero 6; Hoyero 7; Hoyero 8; Hoyero 9; Hoyero 10; Hoyero 1; Hoyero 2; Hoyero 3; Hoyero 4; Hoyero 11; Hoyero 12; Hoyero 13; Hoyero 14; Hoyero 15 | 2160h | 59días | 1,447 |
| 51 | 1.3.3.2 | Izado de postes | 25d | 2024-11-27 | 2025-01-27 | 50SS | 0d |  |  | Grúa 2; Grúa 3; Grúa 4; Grúa 5 | 600h | 62días | 708 |
| 52 | 1.3.3.3 | Cimentaciones | 3d | 2025-01-22 | 2025-01-27 | 51FF | 0d |  |  | Brigada Ligera 1; Brigada Ligera 2; Brigada Ligera 3; Brigada Ligera 4; Brigada Ligera 5 | 90h | 6días | 87 |
| 53 | 1.3.3.4 | Retenidas | 15d | 2025-01-29 | 2025-03-03 | 52 | 0d |  |  | Brigada Ligera 2; Brigada Ligera 3; Brigada Ligera 1; Brigada Ligera 4; Brigada Ligera 5; Canasto 2 | 540h | 34días | 739 |
| 54 | 1.3.3.5 | Armados MT y BT | 30d | 2025-03-05 | 2025-05-14 | 53 | 0d |  |  | Canasto 1; Canasto 2; Canasto 3; Canasto 4; Canasto 5 | 900h | 71días | 1,180 |
| 55 | 1.3.3.6 | Tendido de Conductor MT y BT | 25d | 2025-05-16 | 2025-07-11 | 54 | 0d |  |  | Canasto 2; Canasto 3; Canasto 4; Canasto 5; Canasto 1 | 750h | 57días | 43,383 |
| 56 | 1.3.3.7 | Puesta a Tierra | 10d | 2025-07-14 | 2025-08-04 | 55 | 0d |  |  | Canasto 3; Canasto 4; Canasto 1; Canasto 5; Canasto 2 | 300h | 22días | 488 |
| 57 | 1.3.3.8 | Conexiones y Jumper | 10d | 2025-08-06 | 2025-08-27 | 56 | 0d |  |  | Canasto 1; Canasto 2; Canasto 3; Canasto 4; Canasto 5 | 300h | 22días | 510 |
| 58 | 1.3.3.9 | Transformadores | 4d | 2025-08-29 | 2025-09-05 | 57 | 0d |  |  | Canasto 4; Canasto 5; Grúa 4; Grúa 5; Grúa 3; Grúa 1; Grúa 2; Canasto 1; Canasto 2; Canasto 3 | 240h | 8días | 61 |
| 59 | 1.3.3.10 | Alumbrado Público | 9d | 2025-09-08 | 2025-09-29 | 58 | 0d |  |  | Canasto 4; Canasto 1; Canasto 2; Canasto 3; Canasto 5 | 270h | 22días | 672 |
| 60 | 1.3.3.11 | Etiquetas CT | 1d | 2025-10-01 | 2025-10-01 | 59 | 0d |  |  | Canasto 1; Canasto 2; Canasto 3; Canasto 4; Canasto 5 | 30h | 1días | 89 |
| 61 | 1.3.3.12 | Totalizadores | 6d | 2025-10-03 | 2025-10-15 | 60 | 0d |  |  | Canasto 4; Canasto 5; Canasto 3; Canasto 1; Canasto 2 | 180h | 13días | 89 |
| 62 | 1.3.3.13 | Acometida | 46d | 2025-10-10 | 2026-02-04 | 61SS+3d | 0d |  |  | Brigada de Normalización 1; Brigada de Normalización 2; Brigada de Normalización 3 | 828h | 118días | 2,768 |
| 63 | 1.3.3.14 | Remoción | 12d | 2026-01-14 | 2026-02-13 | 62SS+38d | 0d |  |  | Canasto 1; Grúa 1; Grúa 2; Canasto 2; Grúa 3; Canasto 3 | 432h | 31días | 1,768 |

Notes:
- 35: No se le asigna canasto, pero requiere uno para apertura y cierre de seccionador
- 51: No se le asigna canasto, pero requiere uno para apertura y cierre de seccionador
- 55: Con una grua es suficiente para darle apoyo a los canastos.
